# Ny butik i Århus

Schedule from MS Project, 2019-06-20 to 2019-07-30, costs in kr..
4D

## Calendars

- Standard: Mon-Fri 08:00-12:00, 13:00-17:00; Sat-Sun off.

## Schedule

| ID | WBS | Task | Type | Duration | Start | Finish | Predecessors | Total slack | Cost |
| --- | --- | --- | --- | --- | --- | --- | --- | --- | --- |
| 1 | 1 | Tegning |  | 3d | 2019-06-20 | 2019-06-24 |  | 0d |  |
| 2 | 2 | **Fundament** |  | 8d | 2019-06-25 | 2019-07-04 | 1 | 0d | 1,000 |
| 3 | 2.1 | Udgravning |  | 2d | 2019-06-25 | 2019-06-26 |  | 0d |  |
| 4 | 2.2 | Støbning |  | 1d | 2019-06-27 | 2019-06-27 | 3 | 0d | 1,000 |
| 5 | 2.3 | Afbinding |  | 5d | 2019-06-28 | 2019-07-04 | 4 | 0d |  |
| 6 | 3 | **Råhus** |  | 7d | 2019-07-05 | 2019-07-15 | 2 | 0d | 35,000 |
| 7 | 3.1 | Bærende konstruktioner |  | 3d | 2019-07-05 | 2019-07-09 |  | 0d |  |
| 8 | 3.2 | Ydervægge |  | 2d | 2019-07-10 | 2019-07-11 | 7 | 0d | 15,000 |
| 9 | 3.3 | Tagkonstruktioner |  | 2d | 2019-07-12 | 2019-07-15 | 8 | 0d | 20,000 |
| 10 | 4 | Rejsegilde | milestone | 0d | 2019-07-15 | 2019-07-15 | 6 | 0d |  |
| 11 | 5 | Taglægning |  | 2d | 2019-07-16 | 2019-07-17 | 10 | 0d |  |
| 12 | 6 | Døre og vinduer |  | 2d | 2019-07-18 | 2019-07-19 | 11 | 0d |  |
| 13 | 7 | Faskine |  | 2d | 2019-07-22 | 2019-07-23 | 12 | 0d |  |
| 14 | 8 | Tagrender |  | 5h | 2019-07-24 | 2019-07-24 | 13 | 0d |  |
| 15 | 9 | Maling indvendigt |  | 2d | 2019-07-24 | 2019-07-26 | 14 | 0d |  |
| 16 | 10 | Maling udvendigt |  | 10h | 2019-07-26 | 2019-07-29 | 15 | 0d |  |
| 17 | 11 | Gulv |  | 1d | 2019-07-29 | 2019-07-30 | 16 | 0d |  |
| 18 | 12 | Indvielse | milestone | 0d | 2019-07-30 | 2019-07-30 | 17 | 0d |  |
