# Ny butik i Aarhus

Schedule from MS Project, 2019-06-20 to 2019-07-29, costs in kr.

## Calendars

- Standard: Mon-Fri 08:00-12:00, 13:00-17:00; Sat-Sun off.

## Resources

| Resource | Unit | Rate | Cost per use |
| --- | --- | --- | --- |
| Arkitekt Arne |  | 600 |  |
| Murer Mads |  | 450 |  |
| Jord og Beton Jette |  | 400 |  |
| Tømrer Tom |  | 475 |  |
| Snedker Susanne |  | 450 |  |
| Maler Morten |  | 450 |  |
| VVS Victoria |  | 450 |  |
| Gravemaskine |  | 600 | 2000 |
| Betonblander |  | 150 | 1200 |
| Maling | Liter | 200 |  |
| Beton | Kubikmeter | 1100 |  |
| Forplejning | Kuverter | 50 |  |
| Kontorarktikler |  |  |  |
| Tømrer Torben |  | 475 |  |

## Schedule

| ID | WBS | Task | Type | Duration | Start | Finish | Predecessors | Total slack | Free slack | Cost |
| --- | --- | --- | --- | --- | --- | --- | --- | --- | --- | --- |
| 1 | 1 | Tegning |  | 3d | 2019-06-20 | 2019-06-24 |  | 1d | 0d |  |
| 2 | 2 | **Fundament** |  | 7d | 2019-06-27 | 2019-07-06 | 1FS+2d | 0d |  | 1,000 |
| 3 | 2.1 | Udgravning |  | 2d | 2019-06-27 | 2019-06-28 |  | 1d | 0d |  |
| 4 | 2.2 | Støbning |  | 1d | 2019-07-01 | 2019-07-01 | 3 | 1d | 0d | 1,000 |
| 5 | 2.3 | Afbinding |  | 5ed | 2019-07-01 | 2019-07-06 | 4 | 4.88d |  |  |
| 6 | 3 | **Råhus** |  | 4.25d | 2019-07-08 | 2019-07-12 | 2 | 0d |  | 35,000 |
| 7 | 3.1 | Bærende konstruktioner |  | 3d | 2019-07-08 | 2019-07-10 |  | 0d |  |  |
| 8 | 3.2 | Ydervægge |  | 2d | 2019-07-10 | 2019-07-12 | 7FS-2.5% | 0d |  | 15,000 |
| 9 | 3.3 | Tagkonstruktioner |  | 2d | 2019-07-10 | 2019-07-12 | 8SS | 0d |  | 20,000 |
| 10 | 4 | Rejsegilde | milestone | 0d | 2019-07-12 | 2019-07-12 | 6 | 0d |  |  |
| 11 | 5 | Taglægning |  | 10d | 2019-07-12 | 2019-07-26 | 10 | 0d |  |  |
| 12 | 6 | Døre og vinduer |  | 2d | 2019-07-12 | 2019-07-16 | 11SS | 7d | 0d |  |
| 13 | 7 | Faskine |  | 2d | 2019-07-01 | 2019-07-02 | 3 | 15.38d | 7.25d |  |
| 14 | 8 | Tagrender |  | 5h | 2019-07-12 | 2019-07-12 | 13, 12SS | 8.12d |  |  |
| 15 | 9 | Maling udvendigt |  | 10h | 2019-07-25 | 2019-07-26 | 14, 11FF | 0d |  |  |
| 16 | 10 | Maling indvendigt |  | 2d | 2019-07-16 | 2019-07-18 | 12 | 7d | 0d |  |
| 17 | 11 | Gulv |  | 1d | 2019-07-17 | 2019-07-18 | 16FS-5% | 7d |  |  |
| 18 | 12 | Indvielse | milestone | 0d | 2019-07-29 | 2019-07-29 | 17, 15FS+1d | 0d |  |  |
