# Ny butik i Aarhus

Schedule from MS Project, 2019-06-20 to 2019-07-31, costs in kr.

## Calendars

- Standard: Mon-Fri 08:00-12:00, 13:00-17:00; Sat-Sun off.

## Resources

| Resource | Unit | Rate | Cost per use | Notes |
| --- | --- | --- | --- | --- |
| Arkitekt Arne |  | 600 |  |  |
| Murer Mads |  | 450 |  | Der er aftalt lønstigning fra d. 1 |
| Jord og Beton Jette |  | 400 |  | Der er aftalt lønstigning fra d. 1 |
| Tømrer Tom |  | 475 |  |  |
| Snedker Susanne |  | 450 |  |  |
| Maler Morten |  | 450 |  | Der er aftalt lønstigning fra d. 1 |
| VVS Victoria |  | 450 |  | Der er aftalt lønstigning fra d. 1 |
| Gravemaskine |  | 600 | 2000 |  |
| Betonblander |  | 150 | 1200 |  |
| Maling | Liter | 200 |  |  |
| Beton | Kubikmeter | 1100 |  |  |
| Forplejning | Kuverter | 50 |  |  |
| Kontorarktikler |  |  |  |  |
| Tømrer Torben |  | 475 |  |  |

## Schedule

| ID | WBS | Task | Type | Duration | Start | Finish | Predecessors | Total slack | Free slack | Resources | Work | Cost |
| --- | --- | --- | --- | --- | --- | --- | --- | --- | --- | --- | --- | --- |
| 1 | 1 | Tegning |  | 3d | 2019-06-20 | 2019-06-26 |  | 0d |  | Arkitekt Arne | 24h | 14,400 |
| 2 | 2 | **Fundament** |  | 6d | 2019-06-28 | 2019-07-08 | 1FS+2d | 0d |  |  | 48h | 27,240 |
| 3 | 2.1 | Udgravning |  | 2d | 2019-06-28 | 2019-07-02 |  | 0d |  | Gravemaskine; Jord og Beton Jette | 32h | 18,280 |
| 4 | 2.2 | Støbning |  | 1d | 2019-07-02 | 2019-07-03 | 3 | 0d |  | Beton [2 Kubikmeter]; Betonblander; Jord og Beton Jette | 16h | 8,960 |
| 5 | 2.3 | Afbinding |  | 5ed | 2019-07-03 | 2019-07-08 | 4 | 0d |  |  |  |  |
| 6 | 3 | **Råhus** |  | 4.25d | 2019-07-08 | 2019-07-12 | 2 | 0d |  |  | 56h | 61,560 |
| 7 | 3.1 | Bærende konstruktioner |  | 3d | 2019-07-08 | 2019-07-11 |  | 0d |  | Tømrer Tom | 24h | 11,400 |
| 8 | 3.2 | Ydervægge |  | 2d | 2019-07-11 | 2019-07-12 | 7FS-2.5% | 0d |  | Murer Mads | 16h | 22,560 |
| 9 | 3.3 | Tagkonstruktioner |  | 2d | 2019-07-11 | 2019-07-12 | 8SS | 0d |  | Tømrer Tom | 16h | 27,600 |
| 10 | 4 | Rejsegilde | milestone | 0d | 2019-07-12 | 2019-07-15 | 6 | 0d |  | Arkitekt Arne; Forplejning [10 Kuverter]; Jord og Beton Jette; Maler Morten; Murer Mads; Snedker Susanne; Tømrer Tom; Tømrer Torben; VVS Victoria |  | 500 |
| 11 | 5 | Taglægning |  | 10d | 2019-07-16 | 2019-07-29 | 10 | 0d |  | Tømrer Tom | 80h | 38,000 |
| 12 | 6 | Døre og vinduer |  | 2d | 2019-07-16 | 2019-07-17 | 11SS | 6.75d | 0d | Tømrer Tom | 16h | 7,600 |
| 13 | 7 | Faskine |  | 2d | 2019-07-02 | 2019-07-04 | 3 | 15.38d | 7.25d | Gravemaskine; Jord og Beton Jette | 32h | 18,320 |
| 14 | 8 | Tagrender |  | 5h | 2019-07-16 | 2019-07-16 | 13, 12SS | 8.12d |  | VVS Victoria | 5h | 2,362.5 |
| 15 | 9 | Maling udvendigt |  | 10h | 2019-07-26 | 2019-07-29 | 14, 11FF | 0d |  | Maling [10 Liter]; Maler Morten | 10h | 6,725 |
| 16 | 10 | Maling indvendigt |  | 2d | 2019-07-18 | 2019-07-19 | 12 | 6.75d | 0d | Maler Morten | 16h | 7,560 |
| 17 | 11 | Gulv |  | 1d | 2019-07-19 | 2019-07-22 | 16FS-5% | 6.75d |  | Snedker Susanne | 8h | 3,600 |
| 18 | 12 | Indvielse | milestone | 0d | 2019-07-30 | 2019-07-31 | 17, 15FS+1d | 0d |  | Arkitekt Arne; Betonblander; Forplejning [20 Kuverter]; Gravemaskine; Jord og Beton Jette; Maler Morten; Murer Mads; Snedker Susanne; Tømrer Tom; Tømrer Torben; VVS Victoria |  | 4,200 |
