# Ressourcetyper

Schedule from MS Project, 2010-10-22 to 2010-11-29, costs in kr.
4D Konsulenterne A/S

## Calendars

- Standard: Mon-Fri 08:00-12:00, 13:00-17:00; Sat-Sun off.

## Resources

| Resource | Rate |
| --- | --- |
| Arkitekt Arne | 600 |
| Murer Mads | 472.5 |
| Jord og beton Jette | 420 |
| Tømrer Tom | 475 |
| Snedker Susanne | 475 |
| Maler Morten | 472.5 |
| VVS Victoria | 472.5 |

## Schedule

| ID | WBS | Task | Type | Duration | Start | Finish | Predecessors | Total slack | Free slack | Resources | Work | Cost |
| --- | --- | --- | --- | --- | --- | --- | --- | --- | --- | --- | --- | --- |
| 1 | 1 | **Ny butik i Århus** |  | 27d | 2010-10-22 | 2010-11-29 |  | 0d |  |  | 247h | 118,447.5 |
| 2 | 1.1 | Tegning |  | 3d | 2010-10-22 | 2010-10-26 |  | 0d |  | Arkitekt Arne | 24h | 14,400 |
| 3 | 1.2 | **Fundament** |  | 6d | 2010-10-29 | 2010-11-07 | 2FS+2d | 0d |  |  | 16h | 6,720 |
| 4 | 1.2.1 | Udgravning |  | 2d | 2010-10-29 | 2010-11-01 |  | 0d |  | Jord og beton Jette | 16h | 6,720 |
| 5 | 1.2.2 | Støbning |  | 1d | 2010-11-02 | 2010-11-02 | 4 | 0d |  |  |  |  |
| 6 | 1.2.3 | Afbinding |  | 5ed | 2010-11-02 | 2010-11-07 | 5 | 1.88d |  |  |  |  |
| 7 | 1.3 | **Råhus** |  | 5d | 2010-11-08 | 2010-11-12 | 6 | 0d |  |  | 56h | 26,560 |
| 8 | 1.3.1 | Bærende konstruktioner |  | 3d | 2010-11-08 | 2010-11-10 |  | 0d |  | Tømrer Tom | 24h | 11,400 |
| 9 | 1.3.2 | Ydervægge |  | 2d | 2010-11-11 | 2010-11-12 | 8 | 0d |  | Murer Mads | 16h | 7,560 |
| 10 | 1.3.3 | Tag |  | 2d | 2010-11-11 | 2010-11-12 | 9SS | 0d |  | Tømrer Tom | 16h | 7,600 |
| 11 | 1.4 | Rejsegilde | milestone | 0d | 2010-11-12 | 2010-11-12 | 10, 9 | 0d |  |  |  |  |
| 12 | 1.5 | Taglægning |  | 10d | 2010-11-15 | 2010-11-26 | 11 | 0d |  | Tømrer Tom | 80h | 38,000 |
| 13 | 1.6 | Døre og vinduer |  | 2d | 2010-11-15 | 2010-11-16 | 12SS | 5d | 0d | Snedker Susanne | 16h | 7,600 |
| 14 | 1.7 | Faskine |  | 2d | 2010-11-03 | 2010-11-04 | 5 | 11.12d | 6d | Jord og beton Jette | 16h | 6,720 |
| 15 | 1.8 | Tagrender |  | 5h | 2010-11-15 | 2010-11-15 | 14, 13SS | 5.12d | 0d | Murer Mads | 5h | 2,362.5 |
| 16 | 1.9 | Maling udvendigt |  | 10h | 2010-11-15 | 2010-11-16 | 15 | 5.12d | 0.12d | Maler Morten | 10h | 4,725 |
| 17 | 1.10 | Gulv |  | 1d | 2010-11-17 | 2010-11-17 | 16, 13 | 5d |  | Snedker Susanne | 8h | 3,800 |
| 18 | 1.11 | Maling indvendigt |  | 2d | 2010-11-25 | 2010-11-26 | 17, 12FF | 0d |  | Maler Morten | 16h | 7,560 |
| 19 | 1.12 | Indvielse | milestone | 0d | 2010-11-29 | 2010-11-29 | 18FS+1d, 13 | 0d |  |  |  |  |
