# Implementering af Webside

Schedule from MS Project, 2017-04-03 to 2017-07-05, costs in kr, A marks actual dates.
WebDesign A/S

## Calendars

- Standard: Mon-Fri 08:00-12:00, 13:00-17:00; Sat-Sun off.

## Resources

| Resource | Rate | Cost per use |
| --- | --- | --- |
| Peter Wulf | 575 | 500 |
| Søren Novotny | 345 | 500 |
| Mikker Junker | 266 |  |
| Thomas Riis | 455 | 500 |
| Lars Thorsen | 175 |  |
| Jon Rosengård | 28 |  |
| Brian Adel | 203 |  |
| Morten Borre | 450 |  |
| Peter Kastrup | 566 |  |

## Schedule

| ID | WBS | Task | Type | Duration | Start | Finish | Predecessors | Complete | Remaining | Total slack | Free slack | Resources | Work | Actual work | Cost | Actual cost |
| --- | --- | --- | --- | --- | --- | --- | --- | --- | --- | --- | --- | --- | --- | --- | --- | --- |
| 1 | 1 | **Koncept** |  | 18d | 2017-04-03 A | 2017-04-26 |  | 96% | 0.69d | 50d |  |  | 208h | 200h | 74,612 | 70,472 |
| 2 | 1.1 | Evaluere de aktuelle systemer |  | 5d | 2017-04-03 A | 2017-04-07 A |  | 100% |  |  |  | Peter Wulf | 40h | 40h | 23,500 | 23,500 |
| 3 | 1.2 | **Definition af krav** |  | 5d | 2017-04-10 A | 2017-04-14 A | 2 | 100% |  |  |  |  | 104h | 104h | 19,992 | 19,992 |
| 4 | 1.2.1 | Definere brugerkrav |  | 5d | 2017-04-10 A | 2017-04-14 A |  | 100% |  |  |  | Brian Adel | 40h | 40h | 8,120 | 8,120 |
| 5 | 1.2.2 | Definere indholdskrav |  | 3d | 2017-04-10 A | 2017-04-12 A | 2 | 100% |  |  |  | Brian Adel | 24h | 24h | 4,872 | 4,872 |
| 6 | 1.2.3 | Definere systemkrav |  | 3d | 2017-04-10 A | 2017-04-12 A | 2 | 100% |  |  |  | Lars Thorsen | 24h | 24h | 4,200 | 4,200 |
| 7 | 1.2.4 | Definere ejerkrav til server |  | 2d | 2017-04-10 A | 2017-04-11 A | 2 | 100% |  |  |  | Lars Thorsen | 16h | 16h | 2,800 | 2,800 |
| 8 | 1.3 | Definere bestemte funktioner |  | 1d | 2017-04-17 A | 2017-04-17 A | 4, 7, 6 | 100% |  |  |  | Thomas Riis | 8h | 8h | 4,140 | 4,140 |
| 9 | 1.4 | Definere risici og risikostyringsmetode |  | 4d | 2017-04-18 A | 2017-04-21 A | 8 | 100% |  |  |  | Thomas Riis | 32h | 32h | 15,060 | 15,060 |
| 10 | 1.5 | Oprette projektplan |  | 2d | 2017-04-24 A | 2017-04-25 A | 9 | 100% |  |  |  | Thomas Riis | 16h | 16h | 7,780 | 7,780 |
| 11 | 1.6 | Underrette Web-udviklingsgruppe |  | 1d | 2017-04-26 | 2017-04-26 | 10 |  |  | 50d |  | Thomas Riis | 8h |  | 4,140 |  |
| 12 | 2 | **Design af Web-sted** |  | 22d | 2017-04-27 A | 2017-05-26 |  | 54% | 10.15d | 28d |  |  | 208h | 112h | 65,072 | 27,992 |
| 13 | 2.1 | **Design af brugergrænseflade** |  | 12d | 2017-04-27 A | 2017-05-12 |  | 93% | 0.8d | 0d |  |  | 120h | 112h | 29,392 | 27,992 |
| 14 | 2.1.1 | Fastlægge Web-stedets layout |  | 8d | 2017-04-27 A | 2017-05-08 A | 1, 11 | 100% |  |  |  | Brian Adel | 64h | 64h | 12,992 | 12,992 |
| 15 | 2.1.2 | Fastlægge datakæder |  | 4d | 2017-05-09 A | 2017-05-12 | 14 | 75% | 1d | 0d |  | Lars Thorsen | 32h | 24h | 5,600 | 4,200 |
| 16 | 2.1.3 | Fastlægge, hvordan funktionerne skal implementeres |  | 3d | 2017-05-09 A | 2017-05-11 A | 14 | 100% |  |  |  | Morten Borre | 24h | 24h | 10,800 | 10,800 |
| 17 | 2.1.4 | Design færdiggjort | milestone | 0d | 2017-05-12 | 2017-05-12 | 15, 16 |  |  | 0d |  |  |  |  |  |  |
| 18 | 2.2 | **Design af serveropsætning** |  | 4d | 2017-05-15 | 2017-05-18 | 17 |  |  | 0d |  |  | 40h |  | 14,440 |  |
| 19 | 2.2.1 | Fastlægge det anslåede forbrug af diskplads |  | 0.5d | 2017-05-15 | 2017-05-15 |  |  |  | 0.5d |  | Lars Thorsen | 4h |  | 700 |  |
| 20 | 2.2.2 | Fastlægge den anslåede trafik |  | 0.5d | 2017-05-15 | 2017-05-15 |  |  |  | 0.5d |  | Brian Adel | 4h |  | 812 |  |
| 21 | 2.2.3 | Designe adgangstilladelse |  | 1d | 2017-05-15 | 2017-05-15 |  |  |  | 0d |  | Mikker Junker | 8h |  | 2,128 |  |
| 22 | 2.2.4 | Designe skema med test- og opsætningsomfang |  | 3d | 2017-05-16 | 2017-05-18 | 19, 20, 21 |  |  | 0d |  | Morten Borre | 24h |  | 10,800 |  |
| 23 | 2.2.5 | Kommunikere med serverhandlinger | inactive | 2d | 2017-05-19 | 2017-05-22 | 22 |  |  | 32d | 0d | Peter Kastrup | 16h |  | 9,056 |  |
| 24 | 2.2.6 | Server-sted installeret | milestone | 0d | 2017-05-18 | 2017-05-18 | 23 |  |  | 34d |  |  |  |  |  |  |

| ID | WBS | Task | Type | Duration | Start | Finish | Predecessors | Complete | Remaining | Total slack | Free slack | Resources | Work | Actual work | Cost | Actual cost |
| --- | --- | --- | --- | --- | --- | --- | --- | --- | --- | --- | --- | --- | --- | --- | --- | --- |
| 25 | 2.3 | **Udvikling af infrastruktur for serversupport** |  | 6d | 2017-05-19 | 2017-05-26 |  |  |  | 0d |  |  | 48h |  | 21,240 |  |
| 26 | 2.3.1 | Fastlægge virkning på netværk |  | 2d | 2017-05-19 | 2017-05-22 | 22 |  |  | 0d |  | Lars Thorsen | 16h |  | 2,800 |  |
| 27 | 2.3.2 | Fastlægge, hvilke ændringer der skal foretages |  | 3d | 2017-05-23 | 2017-05-25 | 26 |  |  | 0d |  | Peter Wulf | 24h |  | 14,300 |  |
| 28 | 2.3.3 | Kommunikere med supportgruppen |  | 1d | 2017-05-26 | 2017-05-26 | 27 |  |  | 0d |  | Thomas Riis | 8h |  | 4,140 |  |
| 29 | 2.3.4 | Supportkrav opfyldt | milestone | 0d | 2017-05-26 | 2017-05-26 | 28 |  |  | 0d |  |  |  |  |  |  |
| 30 | 3 | **Udvikling af Web-sted** |  | 55d? | 2017-04-13 A | 2017-06-28 |  | 30% | 38.56d? | 0d |  |  | 1016h | 232h | 256,576 | 48,986 |
| 31 | 3.1 | **Oprettelse af sider og hyperlinks** |  | 18d | 2017-05-15 A | 2017-06-07 |  | 4% | 17.29d | 1d |  |  | 392h | 6h | 105,728 | 2,570 |
| 32 | 3.1.1 | Oprette HTML-typografiskabelon |  | 3d | 2017-05-15 A | 2017-05-17 | 17 | 25% | 2.25d | 1d | 0d | Søren Novotny | 24h | 6h | 8,780 | 2,570 |
| 33 | 3.1.2 | Fastlægge udviklingsværktøj |  | 1d | 2017-05-15 | 2017-05-15 | 17 |  |  | 3d | 2d | Mikker Junker | 8h |  | 2,128 |  |
| 34 | 3.1.3 | Udvikling |  | 15d | 2017-05-18 | 2017-06-07 | 32, 33 |  |  | 1d | 0d | Søren Novotny; Mikker Junker; Lars Thorsen | 360h |  | 94,820 |  |
| 35 | 3.2 | **Udviklingsfunktioner** |  | 15d | 2017-05-15 A | 2017-06-02 |  | 25% | 11.25d | 18d |  |  | 120h | 30h | 3,360 | 840 |
| 36 | 3.2.1 | Oprette evt. brugerdefinerede funktioner |  | 15d | 2017-05-15 A | 2017-06-02 | 17 | 25% | 11.25d | 18d | 3d | Jon Rosengård | 120h | 30h | 3,360 | 840 |
| 37 | 3.2.2 | Integrere i Web-sted | inactive | 4d | 2017-06-08 | 2017-06-13 | 34, 36 |  |  | 3d |  | Jon Rosengård | 32h |  | 896 |  |
| 38 | 3.3 | **Overførsel/integration af oplysninger** |  | 27d? | 2017-04-13 A | 2017-05-19 |  | 91% | 2.5d? | 20d |  |  | 216h | 196h | 52,476 | 45,576 |
| 39 | 3.3.1 | Fastlægge, hvilke oplysninger der skal flyttes/konverteres |  | 3d | 2017-04-13 A | 2017-04-17 A | 5 | 100% |  |  |  | Brian Adel | 24h | 24h | 4,872 | 4,872 |
| 40 | 3.3.2 | Prioritere konvertering af oplysninger |  | 2d | 2017-04-18 A | 2017-04-19 A | 39 | 100% |  |  |  | Brian Adel | 16h | 16h | 3,248 | 3,248 |
| 41 | 3.3.3 | Angive standarder for konvertering af oplysninger |  | 2d | 2017-04-20 A | 2017-04-21 A | 40 | 100% |  |  |  | Peter Kastrup | 16h | 16h | 9,056 | 9,056 |
| 42 | 3.3.4 | Implementere overførsel og konvertering af oplysninger |  | 15d? | 2017-04-24 A | 2017-05-12 A | 41 | 100% |  |  |  | Lars Thorsen | 120h | 120h | 21,000 | 21,000 |
| 43 | 3.3.5 | Teste konverteringsformater |  | 5d | 2017-05-15 A | 2017-05-19 | 42 | 50% | 2.5d | 20d |  | Søren Novotny | 40h | 20h | 14,300 | 7,400 |
| 44 | 3.4 | **Test** |  | 23d? | 2017-05-29 | 2017-06-28 |  |  |  | 0d |  |  | 288h |  | 95,012 |  |
| 45 | 3.4.1 | Oprette testplan |  | 4d | 2017-05-29 | 2017-06-01 | 29 |  |  | 0d |  | Peter Kastrup | 32h |  | 18,112 |  |
| 46 | 3.4.2 | Teste sider |  | 10d? | 2017-06-02 | 2017-06-15 | 34SS+10d, 45 |  |  | 0d |  | Jon Rosengård | 80h |  | 2,240 |  |
| 47 | 3.4.3 | Teste hyperlinks |  | 6d | 2017-06-09 | 2017-06-16 | 46FS-5d |  |  | 0d |  | Søren Novotny | 48h |  | 17,060 |  |
| 48 | 3.4.4 | Teste brugervenlighed |  | 8d | 2017-06-19 | 2017-06-28 | 34, 37, 43, 45, 46, 47 |  |  | 0d |  | Morten Borre | 64h |  | 28,800 |  |
| 49 | 3.4.5 | Teste belastning |  | 8d | 2017-06-19 | 2017-06-28 | 34, 37, 43, 45, 46, 47 |  |  | 0d |  | Morten Borre | 64h |  | 28,800 |  |

| ID | WBS | Task | Type | Duration | Start | Finish | Predecessors | Total slack | Free slack | Resources | Work | Cost |
| --- | --- | --- | --- | --- | --- | --- | --- | --- | --- | --- | --- | --- |
| 50 | 4 | **Installation** |  | 25d? | 2017-06-01 | 2017-07-05 |  | 0d |  |  | 216h | 54,708 |
| 51 | 4.1 | Flytte sted til den offentlige server |  | 2d | 2017-06-19 | 2017-06-20 | 34, 37, 43, 45, 46, 47 | 11d |  | Jon Rosengård | 16h | 448 |
| 52 | 4.2 | Fastlægge installationsplan |  | 5d | 2017-06-01 | 2017-06-07 | 30FS-20d | 0d |  | Jon Rosengård | 40h | 1,120 |
| 53 | 4.3 | Kommunikere installationsplan til brugere |  | 10d | 2017-06-08 | 2017-06-21 | 52 | 0d |  | Thomas Riis | 80h | 36,900 |
| 54 | 4.4 | Forestå brugerundervisning |  | 10d? | 2017-06-08 | 2017-06-21 | 52 | 0d |  | Brian Adel | 80h | 16,240 |
| 55 | 4.5 | Udsende intern pressemeddelelse | inactive | 10d | 2017-06-08 | 2017-06-21 | 52 | 0d |  | Morten Borre | 80h | 36,000 |
| 56 | 4.6 | Web-sted installeret | milestone | 0d | 2017-07-05 | 2017-07-05 | 53FS+10d, 54FS+10d, 55FS+10d | 0d |  |  |  |  |
| 57 | 5 | **Support** |  | 28d | 2017-05-29 | 2017-07-05 |  | 0d |  |  | 136h | 64,152 |
| 58 | 5.1 | Fastlægge, hvilke supportressourcer der er nødvendige |  | 4d | 2017-05-29 | 2017-06-01 | 29 | 11d | 0d | Mikker Junker | 32h | 8,512 |
| 59 | 5.2 | Foretage ændringer i personalesammensætning |  | 5d | 2017-06-02 | 2017-06-08 | 58 | 11d | 0d | Peter Kastrup | 40h | 22,640 |
| 60 | 5.3 | Fastlægge supportmetode for brugerne |  | 3d | 2017-06-09 | 2017-06-13 | 59 | 11d | 0d | Peter Wulf | 24h | 14,300 |
| 61 | 5.4 | Fastlægge supportproces |  | 5d | 2017-06-14 | 2017-06-20 | 60 | 11d |  | Thomas Riis | 40h | 18,700 |
| 62 | 5.5 | Support etableret | milestone | 0d | 2017-07-05 | 2017-07-05 | 56 | 0d |  |  |  |  |
