# Ny butik i Aarhus

Schedule from MS Project, 2019-06-20 to 2019-08-05, costs in kr.

## Calendars

- Standard: Mon-Fri 08:00-12:00, 13:00-17:00; Sat-Sun off.

## Resources

| Resource | Unit | Rate | Cost per use |
| --- | --- | --- | --- |
| Arkitekt Arne |  | 600 |  |
| Murer Mads |  | 450 |  |
| Jord og Beton Jette |  | 400 |  |
| Tømrer Tom |  | 475 |  |
| Snedker Susanne |  | 450 |  |
| Maler Morten |  | 450 |  |
| VVS Victoria |  | 450 |  |
| Gravemaskine |  | 600 | 2000 |
| Betonblander |  | 150 | 1200 |
| Maling | Liter | 200 |  |
| Beton | Kubikmeter | 1100 |  |
| Forplejning | Kuverter | 50 |  |
| Kontorarktikler |  |  |  |
| Tømrer Torben |  | 475 |  |

## Schedule

| ID | WBS | Task | Type | Duration | Start | Finish | Predecessors | Total slack | Free slack | Cost |
| --- | --- | --- | --- | --- | --- | --- | --- | --- | --- | --- |
| 1 | 1 | Tegning |  | 4d | 2019-06-20 | 2019-06-25 |  | 0d |  |  |
| 2 | 2 | **Fundament** |  | 7d | 2019-06-28 | 2019-07-08 | 1FS+2d | 0d |  | 1,000 |
| 3 | 2.1 | Udgravning |  | 2d | 2019-06-28 | 2019-07-01 |  | 0d |  |  |
| 4 | 2.2 | Støbning |  | 2d | 2019-07-02 | 2019-07-03 | 3 | 0d |  | 1,000 |
| 5 | 2.3 | Afbinding |  | 5ed | 2019-07-03 | 2019-07-08 | 4 | 1.88d |  |  |
| 6 | 3 | **Råhus** |  | 9.75d | 2019-07-09 | 2019-07-22 | 2 | 0d |  | 35,000 |
| 7 | 3.1 | Bærende konstruktioner |  | 5d | 2019-07-09 | 2019-07-15 |  | 0d |  |  |
| 8 | 3.2 | Ydervægge |  | 4d | 2019-07-12 | 2019-07-18 | 7FS-2.5% | 0d |  | 15,000 |
| 9 | 3.3 | Tagkonstruktioner |  | 6d | 2019-07-12 | 2019-07-22 | 8SS | 0d |  | 20,000 |
| 10 | 4 | Rejsegilde | milestone | 0d | 2019-07-22 | 2019-07-22 | 6 | 0d |  |  |
| 11 | 5 | **Ydre konstruktioner** |  | 10d | 2019-07-22 | 2019-08-05 |  | 0d |  |  |
| 12 | 5.1 | Taglægning |  | 10d | 2019-07-22 | 2019-08-05 | 10 | 0d |  |  |
| 13 | 5.2 | Døre og vinduer |  | 4d | 2019-07-22 | 2019-07-26 | 12SS | 0.5d | 0d |  |
| 14 | 5.3 | Faskine |  | 2d | 2019-07-22 | 2019-07-24 | 10 | 2.38d | 0d |  |
| 15 | 5.4 | Tagrender |  | 5h | 2019-07-24 | 2019-07-25 | 14, 13SS | 2.38d | 0d |  |
| 16 | 5.5 | Maling udvendigt |  | 4d | 2019-07-25 | 2019-07-31 | 15 | 2.38d | 1.88d |  |
| 17 | 6 | **Maling og gulv** |  | 5.5d | 2019-07-26 | 2019-08-05 |  | 0.5d |  |  |
| 18 | 6.1 | Maling indvendigt |  | 5d | 2019-07-26 | 2019-08-02 | 13 | 0.5d | 0d |  |
| 19 | 6.2 | Gulv |  | 3d | 2019-07-31 | 2019-08-05 | 18FS-5% | 0.5d | 0d |  |
| 20 | 7 | Indvielse | milestone | 0d | 2019-08-05 | 2019-08-05 | 19, 16FS+1d | 0.5d |  |  |
