# Ny butik i Aarhus

Schedule from MS Project, 2019-06-20 to 2019-08-01, costs in kr, A marks actual dates.

## Calendars

- Standard: Mon-Fri 08:00-12:00, 13:00-17:00; Sat-Sun off.

## Resources

| Resource | Unit | Rate | Cost per use | Notes |
| --- | --- | --- | --- | --- |
| Arkitekt Arne |  | 600 |  |  |
| Murer Mads |  | 450 |  | Der er aftalt lønstigning fra d. 1 |
| Jord og Beton Jette |  | 400 |  | Der er aftalt lønstigning fra d. 1 |
| Tømrer Tom |  | 475 |  |  |
| Snedker Susanne |  | 450 |  |  |
| Maler Morten |  | 450 |  | Der er aftalt lønstigning fra d. 1 |
| VVS Victoria |  | 450 |  | Der er aftalt lønstigning fra d. 1 |
| Gravemaskine |  | 600 | 2000 |  |
| Betonblander |  | 150 | 1200 |  |
| Maling | Liter | 200 |  |  |
| Beton | Kubikmeter | 1100 |  |  |
| Forplejning | Kuverter | 50 |  |  |
| Kontorarktikler |  |  |  |  |
| Tømrer Torben |  | 475 |  |  |

## Schedule

| ID | WBS | Task | Type | Duration | Start | Finish | Predecessors | Complete | Baseline start | Baseline finish | Baseline duration | Total slack | Free slack | Resources | Work | Actual work | Cost | Baseline cost | Actual cost |
| --- | --- | --- | --- | --- | --- | --- | --- | --- | --- | --- | --- | --- | --- | --- | --- | --- | --- | --- | --- |
| 1 | 1 | Tegning |  | 3d | 2019-06-20 A | 2019-06-26 A |  | 100% | 2019-06-20 | 2019-06-26 | 3d |  |  | Arkitekt Arne | 24h | 24h | 14,400 | 14,400 | 14,400 |
| 2 | 2 | **Fundament** |  | 6d | 2019-06-28 A | 2019-07-08 A | 1FS+2d | 100% | 2019-06-28 | 2019-07-08 | 6d |  |  |  | 48h | 48h | 27,240 | 27,240 | 27,240 |
| 3 | 2.1 | Udgravning |  | 2d | 2019-06-28 A | 2019-07-02 A |  | 100% | 2019-06-28 | 2019-07-02 | 2d |  |  | Gravemaskine; Jord og Beton Jette | 32h | 32h | 18,280 | 18,280 | 18,280 |
| 4 | 2.2 | Støbning |  | 1d | 2019-07-02 A | 2019-07-03 A | 3 | 100% | 2019-07-02 | 2019-07-03 | 1d |  |  | Beton [2 Kubikmeter]; Betonblander; Jord og Beton Jette | 16h | 16h | 8,960 | 8,960 | 8,960 |
| 5 | 2.3 | Afbinding |  | 5ed | 2019-07-03 A | 2019-07-08 A | 4 | 100% | 2019-07-03 | 2019-07-08 | 5ed |  |  |  |  |  |  |  |  |
| 6 | 3 | **Råhus** |  | 5d | 2019-07-08 A | 2019-07-15 A | 2 | 100% | 2019-07-08 | 2019-07-12 | 4.25d |  |  |  | 64h | 64h | 65,360 | 61,560 | 65,360 |
| 7 | 3.1 | Bærende konstruktioner |  | 4d | 2019-07-08 A | 2019-07-12 A |  | 100% | 2019-07-08 | 2019-07-11 | 3d |  |  | Tømrer Torben | 32h | 32h | 15,200 | 11,400 | 15,200 |
| 8 | 3.2 | Ydervægge |  | 2d | 2019-07-11 A | 2019-07-15 A | 7FS-2.5% | 100% | 2019-07-11 | 2019-07-12 | 2d |  |  | Murer Mads | 16h | 16h | 22,560 | 22,560 | 22,560 |
| 9 | 3.3 | Tagkonstruktioner |  | 2d | 2019-07-11 A | 2019-07-15 A | 8SS | 100% | 2019-07-11 | 2019-07-12 | 2d |  |  | Tømrer Tom | 16h | 16h | 27,600 | 27,600 | 27,600 |
| 10 | 4 | Rejsegilde | milestone | 0d | 2019-07-15 A | 2019-07-16 A | 6 | 100% | 2019-07-12 | 2019-07-15 | 0d |  |  | Arkitekt Arne; Forplejning [10 Kuverter]; Jord og Beton Jette; Maler Morten; Murer Mads; Snedker Susanne; Tømrer Tom; Tømrer Torben; VVS Victoria |  |  | 500 | 500 | 500 |
| 11 | 5 | Taglægning |  | 10d | 2019-07-16 | 2019-07-30 | 10 |  | 2019-07-16 | 2019-07-29 | 10d | 0d |  | Tømrer Tom | 80h |  | 38,000 | 38,000 |  |
| 12 | 6 | Døre og vinduer |  | 2d | 2019-07-16 | 2019-07-19 | 11SS |  | 2019-07-16 | 2019-07-17 | 2d | 6.5d | 0d | Snedker Susanne | 16h |  | 7,200 |  |  |
| 13 | 7 | Faskine |  | 2d | 2019-07-03 A | 2019-07-05 A | 4 | 100% | 2019-07-03 | 2019-07-05 | 2d |  |  | Gravemaskine; Jord og Beton Jette | 32h | 32h | 18,320 | 18,320 | 18,320 |
| 14 | 8 | Tagrender |  | 5h | 2019-07-16 | 2019-07-17 | 13, 12SS |  | 2019-07-16 | 2019-07-16 | 5h | 8.12d |  | VVS Victoria | 5h |  | 2,362.5 | 2,362.5 |  |
| 15 | 9 | Maling udvendigt |  | 10h | 2019-07-29 | 2019-07-30 | 14, 11FF |  | 2019-07-26 | 2019-07-29 | 10h | 0d |  | Maling [10 Liter]; Maler Morten | 10h |  | 6,725 | 6,725 |  |
| 16 | 10 | Maling indvendigt |  | 2d | 2019-07-19 | 2019-07-23 | 12 |  | 2019-07-18 | 2019-07-19 | 2d | 6.5d | 0d | Maler Morten | 16h |  | 7,560 | 7,560 |  |
| 17 | 11 | Gulv |  | 1d | 2019-07-22 | 2019-07-23 | 16FS-5% |  | 2019-07-19 | 2019-07-22 | 1d | 6.5d |  | Snedker Susanne | 8h |  | 3,600 | 3,600 |  |
| 18 | 12 | Indvielse | milestone | 0d | 2019-07-31 | 2019-08-01 | 17, 15FS+1d |  | 2019-07-30 | 2019-07-31 | 0d | 0d |  | Arkitekt Arne; Betonblander; Forplejning [20 Kuverter]; Gravemaskine; Jord og Beton Jette; Maler Morten; Murer Mads; Snedker Susanne; Tømrer Tom; Tømrer Torben; VVS Victoria |  |  | 4,200 | 4,200 |  |
